# Malware Protection Overhaul

How a schedule from MS Project changed from version to version. A marks actual dates.

## Version 1 (saved 2012-11-15, file Malware Protection Overhaul.mpp)

| ID | WBS | Task | Duration | Start | Finish | Complete | Total float |
| --- | --- | --- | --- | --- | --- | --- | --- |
| 1 | 1 | **Malware Protection Overhaul Project** | 8d? | 2012-11-05 A | 2012-11-14 | 4% | 0d |
| 2 | 1.1 | **Planning** | 1d? | 2012-11-05 A | 2012-11-05 | 32% | 0d |
| 3 |  | Define scope | 1d? | 2012-11-05 A | 2012-11-05 | 95% |  |
| 4 |  | Review scope with Mark | 1d? | 2012-11-05 | 2012-11-05 |  |  |
| 5 |  | Kickoff Meeting - include other teams | 1d? | 2012-11-05 | 2012-11-05 |  |  |
| 6 | 1.2 | **Windows Selection** | 1d? | 2012-11-14 A | 2012-11-14 | 5% | 0d |
| 7 | 1.2.1 | **System Center 2012 (Forefront) Evaluation** | 1d? | 2012-11-14 | 2012-11-14 |  | 0d |
| 8 |  | Console setup | 1d? | 2012-11-14 | 2012-11-14 |  |  |
| 9 |  | Console and client functionality evaluation | 1d? | 2012-11-14 | 2012-11-14 |  |  |
| 10 |  | Document pros and cons | 1d? | 2012-11-14 | 2012-11-14 |  |  |
| 11 |  | Checkpoint: IS Evaluation success? | 1d? | 2012-11-14 | 2012-11-14 |  |  |
| 12 | 1.2.2 | **ESET Evaluation** | 1d? | 2012-11-14 A | 2012-11-14 | 50% | 0d |
| 13 |  | Console setup | 1d | 2012-11-14 A | 2012-11-14 A | 100% |  |
| 14 |  | Console and client functionality evaluation | 1d | 2012-11-14 A | 2012-11-14 A | 100% |  |
| 15 |  | Document pros and cons | 1d? | 2012-11-14 | 2012-11-14 |  |  |
| 16 |  | Checkpoint: IS Evaluation success? | 1d? | 2012-11-14 | 2012-11-14 |  |  |
| 17 | 1.2.3 | **Vendor Demo** | 1d? | 2012-11-14 | 2012-11-14 |  | 0d |
| 18 |  | Determine invitees | 1d? | 2012-11-14 | 2012-11-14 |  |  |
| 19 |  | Determine requirements | 1d? | 2012-11-14 | 2012-11-14 |  |  |
| 20 |  | Demo | 1d? | 2012-11-14 | 2012-11-14 |  |  |
| 21 |  | Team feedback | 1d? | 2012-11-14 | 2012-11-14 |  |  |
| 22 |  | Checkpoint: Team Evaluation success? | 1d? | 2012-11-14 | 2012-11-14 |  |  |
| 23 | 1.2.4 | **Analyze Recommendation and Solution** | 1d? | 2012-11-14 | 2012-11-14 |  | 0d |
| 24 |  | Determine any contract/licensing issues | 1d? | 2012-11-14 | 2012-11-14 |  |  |
| 25 |  | Determine total cost of ownership | 1d? | 2012-11-14 | 2012-11-14 |  |  |
| 26 |  | Determine benefits and concerns | 1d? | 2012-11-14 | 2012-11-14 |  |  |
| 27 |  | Determine support process/structure | 1d? | 2012-11-14 | 2012-11-14 |  |  |
| 28 | 1.2.5 | **Sponsor approval** | 1d? | 2012-11-14 | 2012-11-14 |  | 0d |
| 29 |  | Approval from sponsor | 1d? | 2012-11-14 | 2012-11-14 |  |  |
| 30 | 1.2.6 | **Documentation and communication** | 1d? | 2012-11-14 | 2012-11-14 |  | 0d |
| 31 |  | Helpdesk (awareness only) | 1d? | 2012-11-14 | 2012-11-14 |  |  |
| 32 |  | DITR (awareness only) | 1d? | 2012-11-14 | 2012-11-14 |  |  |
| 33 |  | ITLEADERS (awareness and preparing for early adaptors only) | 1d? | 2012-11-14 | 2012-11-14 |  |  |
| 34 | 1.2.7 | **Pilot rollout (STAKEHOLDERS)** | 1d? | 2012-11-14 | 2012-11-14 |  | 0d |
| 35 |  | Determine pilot rollout team | 1d? | 2012-11-14 | 2012-11-14 |  |  |
| 36 |  | Determine timelines | 1d? | 2012-11-14 | 2012-11-14 |  |  |
| 37 |  | determine pilot rollout strategy | 1d? | 2012-11-14 | 2012-11-14 |  |  |
| 38 |  | Collect feedback | 1d? | 2012-11-14 | 2012-11-14 |  |  |
| 39 |  | Checkpoint: Present pilot rollout feedback to Sponsor | 1d? | 2012-11-14 | 2012-11-14 |  |  |
| 40 | 1.2.8 | **Procurement** | 1d? | 2012-11-14 | 2012-11-14 |  | 0d |
| 41 |  | Negotiate pricing | 1d? | 2012-11-14 | 2012-11-14 |  |  |
| 42 |  | Contract agreement and signature | 1d? | 2012-11-14 | 2012-11-14 |  |  |
| 43 |  | Purchase | 1d? | 2012-11-14 | 2012-11-14 |  |  |
| 44 |  | Reminder: adjust McAfee contract | 1d? | 2012-11-14 | 2012-11-14 |  |  |
| 45 | 1.2.9 | **EARLY ADOPTERS** | 1d? | 2012-11-14 | 2012-11-14 |  | 0d |
| 46 |  | Determine early adopters participants | 1d? | 2012-11-14 | 2012-11-14 |  |  |
| 47 |  | Determine timelines | 1d? | 2012-11-14 | 2012-11-14 |  |  |
| 48 |  | determine beta rollout strategy | 1d? | 2012-11-14 | 2012-11-14 |  |  |
| 49 |  | collect feedback | 1d? | 2012-11-14 | 2012-11-14 |  |  |
| 50 |  | Final Checkpoint: Present all feedback including beta rollout feedback to Sponsor | 1d? | 2012-11-14 | 2012-11-14 |  |  |
| 51 | 1.2.11 | **General Communications** | 1d? | 2012-11-14 | 2012-11-14 |  | 0d |
| 52 |  | to community | 1d? | 2012-11-14 | 2012-11-14 |  |  |
| 53 | 1.2.12 | **Prep Helpdesk for full rollout support** | 1d? | 2012-11-14 | 2012-11-14 |  | 0d |
| 54 |  | any additional training/documentation | 1d? | 2012-11-14 | 2012-11-14 |  |  |
| 55 | 1.2.13 | **Full rollout (COMMUNITY)** | 1d? | 2012-11-14 | 2012-11-14 |  | 0d |
| 56 |  | Provide software to SWRT for distribution | 1d? | 2012-11-14 | 2012-11-14 |  |  |
| 57 | 1.3 | **MAC Selection** | 1d? | 2012-11-14 | 2012-11-14 |  | 0d |
| 58 | 1.3.1 | **Evaluation** | 1d? | 2012-11-14 | 2012-11-14 |  | 0d |
| 59 | 1.3.1.1 | **Sophos Evaluation** | 1d? | 2012-11-14 | 2012-11-14 |  | 0d |
| 60 |  | Console setup | 1d? | 2012-11-14 | 2012-11-14 |  |  |
| 61 |  | Console and client functionality evaluation | 1d? | 2012-11-14 | 2012-11-14 |  |  |
| 62 |  | Document Pros and cons | 1d? | 2012-11-14 | 2012-11-14 |  |  |
| 63 |  | Checkpoint: IS Evaluation success? | 1d? | 2012-11-14 | 2012-11-14 |  |  |
| 64 | 1.3.1.2 | **ESET Evaluation** | 1d? | 2012-11-14 | 2012-11-14 |  | 0d |
| 65 |  | Console setup | 1d? | 2012-11-14 | 2012-11-14 |  |  |
| 66 |  | Console and client functionality evaluation | 1d? | 2012-11-14 | 2012-11-14 |  |  |
| 67 |  | Document pros and cons | 1d? | 2012-11-14 | 2012-11-14 |  |  |
| 68 |  | Checkpoint: IS Evaluation success? | 1d? | 2012-11-14 | 2012-11-14 |  |  |
| 69 | 1.3.2 | **Vendor Demo** | 1d? | 2012-11-14 | 2012-11-14 |  | 0d |
| 70 |  | Determine which vendor(s) to demo | 1d? | 2012-11-14 | 2012-11-14 |  |  |

| ID | WBS | Task | Duration | Start | Finish | Total float |
| --- | --- | --- | --- | --- | --- | --- |
| 71 |  | Determine invitees | 1d? | 2012-11-14 | 2012-11-14 |  |
| 72 |  | Determine requirements | 1d? | 2012-11-14 | 2012-11-14 |  |
| 73 |  | Demo | 1d? | 2012-11-14 | 2012-11-14 |  |
| 74 |  | Team feedback | 1d? | 2012-11-14 | 2012-11-14 |  |
| 75 |  | Checkpoint: Team Evaluation success? | 1d? | 2012-11-14 | 2012-11-14 |  |
| 76 | 1.3.3 | **Analyze Recommendation and Solution** | 1d? | 2012-11-14 | 2012-11-14 | 0d |
| 77 |  | Determine any contract/licensing issues | 1d? | 2012-11-14 | 2012-11-14 |  |
| 78 |  | Determine total cost of ownership | 1d? | 2012-11-14 | 2012-11-14 |  |
| 79 |  | Determine benefits and concerns | 1d? | 2012-11-14 | 2012-11-14 |  |
| 80 |  | Determine support process/structure | 1d? | 2012-11-14 | 2012-11-14 |  |
| 81 | 1.3.4 | **Sponsor approval** | 1d? | 2012-11-14 | 2012-11-14 | 0d |
| 82 |  | Approval from sponsor | 1d? | 2012-11-14 | 2012-11-14 |  |
| 83 | 1.3.5 | **Documentation and communication** | 1d? | 2012-11-14 | 2012-11-14 | 0d |
| 84 |  | Helpdesk (awareness only) | 1d? | 2012-11-14 | 2012-11-14 |  |
| 85 |  | DITR (awareness only) | 1d? | 2012-11-14 | 2012-11-14 |  |
| 86 |  | ITLEADERS (awareness and preparing for early adaptors only) | 1d? | 2012-11-14 | 2012-11-14 |  |
| 87 | 1.3.6 | **Pilot rollout (STAKEHOLDERS)** | 1d? | 2012-11-14 | 2012-11-14 | 0d |
| 88 |  | Determine pilot rollout team | 1d? | 2012-11-14 | 2012-11-14 |  |
| 89 |  | Determine timelines | 1d? | 2012-11-14 | 2012-11-14 |  |
| 90 |  | determine pilot rollout strategy | 1d? | 2012-11-14 | 2012-11-14 |  |
| 91 |  | Collect feedback | 1d? | 2012-11-14 | 2012-11-14 |  |
| 92 |  | Checkpoint: Present pilot rollout feedback to Sponsor | 1d? | 2012-11-14 | 2012-11-14 |  |
| 93 | 1.3.7 | **Procurement** | 1d? | 2012-11-14 | 2012-11-14 | 0d |
| 94 |  | Negotiate pricing | 1d? | 2012-11-14 | 2012-11-14 |  |
| 95 |  | Contract agreement and signature | 1d? | 2012-11-14 | 2012-11-14 |  |
| 96 |  | Purchase | 1d? | 2012-11-14 | 2012-11-14 |  |
| 97 |  | Reminder: adjust McAfee contract | 1d? | 2012-11-14 | 2012-11-14 |  |
| 98 | 1.3.8 | **EARLY ADOPTERS** | 1d? | 2012-11-14 | 2012-11-14 | 0d |
| 99 |  | Determine early adopters participants | 1d? | 2012-11-14 | 2012-11-14 |  |
| 100 |  | Determine timelines | 1d? | 2012-11-14 | 2012-11-14 |  |
| 101 |  | determine beta rollout strategy | 1d? | 2012-11-14 | 2012-11-14 |  |
| 102 |  | collect feedback | 1d? | 2012-11-14 | 2012-11-14 |  |
| 103 |  | Final Checkpoint: Present all feedback including beta rollout feedback to Sponsor | 1d? | 2012-11-14 | 2012-11-14 |  |
| 104 | 1.3.10 | **General Communications** | 1d? | 2012-11-14 | 2012-11-14 | 0d |
| 105 |  | to community | 1d? | 2012-11-14 | 2012-11-14 |  |
| 106 | 1.3.11 | **Prep Helpdesk for full rollout support** | 1d? | 2012-11-14 | 2012-11-14 | 0d |
| 107 |  | any additional training/documentation | 1d? | 2012-11-14 | 2012-11-14 |  |
| 108 | 1.3.12 | **Full rollout (COMMUNITY)** | 1d? | 2012-11-14 | 2012-11-14 | 0d |
| 109 |  | Provide software to SWRT for distribution | 1d? | 2012-11-14 | 2012-11-14 |  |
| 110 | 1.4 | **Project Wrapup** | 1d? | 2012-11-14 | 2012-11-14 | 0d |
| 111 |  | closeout project | 1d? | 2012-11-14 | 2012-11-14 |  |

## Version 2 (saved 2012-11-28, file Malware Protection Overhaul.mpp)

Last finish 2012-11-14 → 2012-12-05 (+21d). Complete tasks 2 → 9.

Added:

| ID | Task | Duration | Start | Finish |
| --- | --- | --- | --- | --- |
| 8 | VM setup | 1d? | 2012-11-14 | 2012-11-14 |
| 14 | VM setup | 1d | 2012-11-14 A | 2012-11-14 A |
| 62 | VM setup | 1d | 2012-11-28 A | 2012-11-28 A |
| 68 | VM setup | 1d | 2012-12-05 A | 2012-12-05 A |

Changed:

| ID | Task | Start | Finish | Duration | Complete | Other |
| --- | --- | --- | --- | --- | --- | --- |
| 1 | **Malware Protection Overhaul Project** |  | 2012-11-14 → 2012-12-05 (+21d) | 8d? → 23d? | 4% → 11% |  |
| 2 | **Planning** |  |  |  | 32% → 67% |  |
| 3 | Define scope |  | 2012-11-05 A | 1d? → 1d | 95% → 100% |  |
| 4 | Review scope with Mark | 2012-11-05 A | 2012-11-05 A | 1d? → 1d | 0% → 100% |  |
| 6 | **Windows Selection** |  |  |  | 5% → 8% |  |
| 12 | Go/No Go? |  |  |  |  | was named Checkpoint: IS Evaluation success? |
| 13 | **ESET Evaluation (v5.0 - Jan 2013)** |  |  |  | 50% → 60% | was named ESET Evaluation |
| 18 | Go/No Go? |  |  |  |  | was named Checkpoint: IS Evaluation success? |
| 24 | Go/No Go? |  |  |  |  | was named Checkpoint: Team Evaluation success? |
| 59 | **MAC Selection** | 2012-11-14 A | 2012-11-14 → 2012-12-05 (+21d) | 1d? → 16d? | 0% → 10% |  |
| 60 | **Evaluation** | 2012-11-14 → 2012-11-28 A (+14d) | 2012-11-14 → 2012-12-05 (+21d) | 1d? → 6d? | 0% → 40% |  |
| 61 | **Sophos Evaluation** | 2012-11-14 → 2012-11-28 A (+14d) | 2012-11-14 → 2012-12-05 (+21d) | 1d? → 6d? | 0% → 20% |  |
| 63 | Console setup | 2012-11-14 → 2012-12-05 (+21d) | 2012-11-14 → 2012-12-05 (+21d) |  |  |  |
| 64 | Console and client functionality evaluation | 2012-11-14 → 2012-11-28 (+14d) | 2012-11-14 → 2012-11-28 (+14d) |  |  |  |
| 65 | Document Pros and cons | 2012-11-14 → 2012-11-28 (+14d) | 2012-11-14 → 2012-11-28 (+14d) |  |  |  |
| 66 | Go/No Go? | 2012-11-14 → 2012-11-28 (+14d) | 2012-11-14 → 2012-11-28 (+14d) |  |  | was named Checkpoint: IS Evaluation success? |
| 67 | **ESET Evaluation (v5.0 - Jan 2013)** | 2012-11-14 → 2012-12-05 A (+21d) | 2012-11-14 → 2012-12-05 (+21d) |  | 0% → 60% | was named ESET Evaluation |
| 69 | Console setup | 2012-11-14 → 2012-12-05 A (+21d) | 2012-11-14 → 2012-12-05 A (+21d) | 1d? → 1d | 0% → 100% |  |
| 70 | Console and client functionality evaluation | 2012-11-14 → 2012-12-05 A (+21d) | 2012-11-14 → 2012-12-05 A (+21d) | 1d? → 1d | 0% → 100% |  |
| 71 | Document pros and cons | 2012-11-14 → 2012-12-05 (+21d) | 2012-11-14 → 2012-12-05 (+21d) |  |  |  |
| 72 | Go/No Go? | 2012-11-14 → 2012-12-05 (+21d) | 2012-11-14 → 2012-12-05 (+21d) |  |  | was named Checkpoint: IS Evaluation success? |

## Version 3 (saved 2012-12-11, file Malware Protection Overhaul.mpp)

Last finish stays 2012-12-05. Complete tasks 9 → 13.

Added:

| ID | Task | Duration | Start | Finish | Resources |
| --- | --- | --- | --- | --- | --- |
| 6 | **Communications** | 1d? | 2012-11-14 A | 2012-11-14 |  |
| 7 | Initial IT Leader meeting presentation | 1d? | 2012-11-14 A | 2012-11-14 A | Andrew |
| 8 | Contact IT Leaders to solicite volunteers for pilot | 1d? | 2012-11-14 | 2012-11-14 | Tim |
| 9 | Checklist for pilot | 1d? | 2012-11-14 | 2012-11-14 | Andrew |
| 30 | Peer school comparion breakdown | 1d? | 2012-11-14 | 2012-11-14 | Andrew |
| 37 | **McAfee License** | 1d? | 2012-11-14 A | 2012-11-14 |  |
| 38 | Understand current McAfee license constraints | 1d | 2012-11-14 A | 2012-11-14 A |  |
| 39 | Adjust McAfee license based on new requirements | 1d? | 2012-11-14 | 2012-11-14 |  |

Changed:

| ID | Task | Start | Finish | Duration | Complete | Total float | Other |
| --- | --- | --- | --- | --- | --- | --- | --- |
| 1 | **Malware Protection Overhaul Project** |  |  |  | 11% → 14% |  |  |
| 2 | **Planning** |  | 2012-11-05 A | 1d? → 1d | 67% → 100% | 0d → none |  |
| 5 | Kickoff Meeting - include other teams | 2012-11-05 A | 2012-11-05 A | 1d? → 1d | 0% → 100% |  |  |
| 10 | **Windows Selection** |  |  |  | 8% → 9% |  |  |
| 12 | VM setup |  |  |  |  |  | resources none → Richard |
| 13 | Console setup |  |  |  |  |  | resources none → Richard |
| 67 | **MAC Selection** |  |  |  | 10% → 12% |  |  |
| 68 | **Evaluation** |  |  |  | 40% → 50% |  |  |
| 69 | **Sophos Evaluation** |  |  |  | 20% → 40% |  |  |
| 71 | Console setup | 2012-12-05 A | 2012-12-05 A | 1d? → 1d | 0% → 100% |  |  |

## Version 4 (saved 2012-12-17, file Malware Protection Overhaul.mpp)

Last finish stays 2012-12-05. Complete tasks 13 → 18.

Changed:

| ID | Task | Start | Finish | Duration | Complete |
| --- | --- | --- | --- | --- | --- |
| 1 | **Malware Protection Overhaul Project** |  |  |  | 14% → 20% |
| 6 | **Communications** |  |  |  | 33% → 83% |
| 8 | Contact IT Leaders to solicite volunteers for pilot | 2012-11-14 A |  |  | 0% → 50% |
| 9 | Checklist for pilot | 2012-11-14 A | 2012-11-14 A | 1d? → 1d | 0% → 100% |
| 10 | **Windows Selection** |  |  |  | 9% → 14% |
| 11 | **System Center 2012 (Forefront) Evaluation** | 2012-11-14 A |  |  | 0% → 20% |
| 12 | VM setup | 2012-11-14 A | 2012-11-14 A | 1d? → 1d | 0% → 100% |
| 29 | **Analyze Recommendation and Solution** | 2012-11-14 A |  |  | 0% → 20% |
| 30 | Peer school comparion breakdown | 2012-11-14 A | 2012-11-14 A | 1d? → 1d | 0% → 100% |
| 31 | Determine any contract/licensing issues |  |  | 1d? → 1d |  |
| 67 | **MAC Selection** |  |  |  | 12% → 17% |
| 68 | **Evaluation** |  |  |  | 50% → 70% |
| 69 | **Sophos Evaluation** |  |  |  | 40% → 80% |
| 72 | Console and client functionality evaluation | 2012-11-28 A | 2012-11-28 A | 1d? → 1d | 0% → 100% |
| 74 | Go/No Go? | 2012-11-28 A | 2012-11-28 A | 1d? → 1d | 0% → 100% |

## Version 5 (saved 2013-01-04, file Malware Protection Overhaul Jan02.mpp)

Last finish 2012-12-05 → 2013-04-05 (+121d). Complete tasks 18 → 22.

Removed: 16 Go/No Go?; 22 Go/No Go?; 28 Go/No Go?; 74 Go/No Go?; 80 Go/No Go?; 87 Checkpoint: Team Evaluation success?; 104 Checkpoint: Present pilot rollout feedback to Sponsor

Changed:

| ID | Task | Start | Finish | Duration | Complete | Total float | Predecessors |
| --- | --- | --- | --- | --- | --- | --- | --- |
| 1 | **Malware Protection Overhaul Project** |  | 2012-12-05 → 2013-04-05 (+121d) | 23d? → 110d? |  |  |  |
| 6 | **Communications** |  | 2012-11-14 A |  | 83% → 100% | 0d → none |  |
| 8 | Contact IT Leaders to solicite volunteers for pilot |  | 2012-11-14 A | 1d? → 1d | 50% → 100% |  |  |
| 10 | **Windows Selection** |  | 2012-11-14 → 2013-04-05 (+142d) | 1d? → 103d? | 14% → 16% |  |  |
| 11 | **System Center 2012 (Forefront) Evaluation** |  | 2012-11-14 → 2013-01-31 (+78d) | 1d? → 57d? | 20% → 50% |  |  |
| 13 | Console setup | 2012-11-14 A | 2012-11-14 A | 1d? → 1d | 0% → 100% |  |  |
| 14 | Console and client functionality evaluation | 2012-11-14 → 2013-01-31 (+78d) | 2012-11-14 → 2013-01-31 (+78d) |  |  |  |  |
| 15 | Document pros and cons | 2012-11-14 → 2013-01-31 (+78d) | 2012-11-14 → 2013-01-31 (+78d) |  |  |  |  |
| 16 | **ESET Evaluation (v5.0 - Jan 2013)** |  | 2012-11-14 → 2013-01-31 (+78d) | 1d? → 57d? | 60% → 75% |  |  |
| 20 | Document pros and cons | 2012-11-14 → 2013-01-31 (+78d) | 2012-11-14 → 2013-01-31 (+78d) |  |  |  |  |
| 21 | **Vendor Demo** | 2012-11-14 A | 2012-11-14 → 2013-02-14 (+92d) | 1d? → 67d | 0% → 7% |  |  |
| 22 | Determine invitees | 2012-11-14 A | 2012-11-14 A | 1d? → 1d | 0% → 100% |  |  |
| 23 | Determine requirements | 2012-11-14 → 2013-02-01 (+79d) | 2012-11-14 → 2013-02-01 (+79d) | 1d? → 1d |  |  |  |
| 24 | Demo | 2012-11-14 → 2013-02-01 (+79d) | 2012-11-14 → 2013-02-14 (+92d) | 1d? → 10d |  |  |  |
| 25 | Team feedback | 2012-11-14 → 2013-02-01 (+79d) | 2012-11-14 → 2013-02-04 (+82d) | 1d? → 2d |  |  |  |
| 26 | **Analyze Recommendation and Solution** |  | 2012-11-14 → 2013-02-19 (+97d) | 1d? → 70d |  |  |  |
| 28 | Determine any contract/licensing issues | 2012-11-14 → 2013-02-15 (+93d) | 2012-11-14 → 2013-02-15 (+93d) |  |  |  | none → 24 |
| 29 | Determine total cost of ownership | 2012-11-14 → 2013-02-15 (+93d) | 2012-11-14 → 2013-02-15 (+93d) | 1d? → 1d |  | none → 0d | none → 24 |
| 30 | Determine benefits and concerns | 2012-11-14 → 2013-02-18 (+96d) | 2012-11-14 → 2013-02-18 (+96d) | 1d? → 1d |  | none → 0d | none → 29 |
| 31 | Determine support process/structure | 2012-11-14 → 2013-02-19 (+97d) | 2012-11-14 → 2013-02-19 (+97d) | 1d? → 1d |  | none → 0d | none → 30 |
| 32 | **Sponsor approval** | 2012-11-14 → 2013-02-19 (+97d) | 2012-11-14 → 2013-02-26 (+104d) | 1d? → 5d |  | 0d → none | none → 26 |
| 33 | Approval from sponsor | 2012-11-14 → 2013-02-19 (+97d) | 2012-11-14 → 2013-02-20 (+98d) |  |  |  |  |
| 34 | **McAfee License** |  | 2012-11-14 → 2013-02-27 (+105d) | 1d? → 76d? |  | 0d → 27d |  |
| 36 | Adjust McAfee license based on new requirements | 2012-11-14 → 2013-02-27 (+105d) | 2012-11-14 → 2013-02-27 (+105d) |  |  | none → 27d | none → 32 |
| 37 | **Documentation and communication** | 2012-11-14 → 2013-02-27 (+105d) | 2012-11-14 → 2013-02-27 (+105d) |  |  | 0d → -15d | none → 32 |
| 38 | Helpdesk (awareness only) | 2012-11-14 → 2013-02-27 (+105d) | 2012-11-14 → 2013-02-27 (+105d) |  |  | none → 27d |  |
| 39 | DITR (awareness only) | 2012-11-14 → 2013-02-27 (+105d) | 2012-11-14 → 2013-02-27 (+105d) |  |  | none → 27d |  |
| 40 | ITLEADERS (awareness and preparing for early adaptors only) | 2012-11-14 → 2013-02-27 (+105d) | 2012-11-14 → 2013-02-27 (+105d) |  |  | none → -15d |  |
| 41 | **Pilot rollout (STAKEHOLDERS)** | 2012-11-14 → 2013-02-26 (+104d) | 2012-11-14 → 2013-03-12 (+118d) | 1d? → 10d |  | 0d → none | none → 32 |
| 42 | Determine pilot rollout team | 2012-11-14 → 2013-02-26 (+104d) | 2012-11-14 → 2013-02-27 (+105d) |  |  |  |  |
| 43 | Determine timelines | 2012-11-14 → 2013-02-26 (+104d) | 2012-11-14 → 2013-02-27 (+105d) |  |  |  |  |
| 44 | determine pilot rollout strategy | 2012-11-14 → 2013-02-26 (+104d) | 2012-11-14 → 2013-02-27 (+105d) |  |  |  |  |
| 45 | Collect feedback | 2012-11-14 → 2013-02-26 (+104d) | 2012-11-14 → 2013-02-27 (+105d) |  |  |  |  |
| 46 | Checkpoint: Present pilot rollout feedback to Sponsor | 2012-11-14 → 2013-02-26 (+104d) | 2012-11-14 → 2013-02-27 (+105d) |  |  |  |  |
| 47 | **Procurement** | 2012-11-14 → 2013-03-12 (+118d) | 2012-11-14 → 2013-03-26 (+132d) | 1d? → 10d |  | 0d → none | none → 41 |
| 48 | Negotiate pricing | 2012-11-14 → 2013-03-12 (+118d) | 2012-11-14 → 2013-03-13 (+119d) |  |  |  |  |
| 49 | Contract agreement and signature | 2012-11-14 → 2013-03-12 (+118d) | 2012-11-14 → 2013-03-13 (+119d) |  |  |  |  |
| 50 | Purchase | 2012-11-14 → 2013-03-12 (+118d) | 2012-11-14 → 2013-03-13 (+119d) |  |  |  |  |
| 51 | Reminder: adjust McAfee contract | 2012-11-14 → 2013-03-12 (+118d) | 2012-11-14 → 2013-03-13 (+119d) |  |  |  |  |
| 52 | **EARLY ADOPTERS** | 2012-11-14 → 2013-03-12 (+118d) | 2012-11-14 → 2013-03-26 (+132d) | 1d? → 10d |  | 0d → none | none → 41 |
| 53 | Determine early adopters participants | 2012-11-14 → 2013-03-12 (+118d) | 2012-11-14 → 2013-03-13 (+119d) |  |  |  |  |
| 54 | Determine timelines | 2012-11-14 → 2013-03-12 (+118d) | 2012-11-14 → 2013-03-13 (+119d) |  |  |  |  |
| 55 | determine beta rollout strategy | 2012-11-14 → 2013-03-12 (+118d) | 2012-11-14 → 2013-03-13 (+119d) |  |  |  |  |
| 56 | collect feedback | 2012-11-14 → 2013-03-12 (+118d) | 2012-11-14 → 2013-03-13 (+119d) |  |  |  |  |
| 58 | **General Communications** | 2012-11-14 → 2013-03-26 (+132d) | 2012-11-14 → 2013-03-28 (+134d) | 1d? → 2d |  | 0d → none | none → 52 |
| 59 | to community | 2012-11-14 → 2013-03-26 (+132d) | 2012-11-14 → 2013-03-27 (+133d) |  |  |  |  |
| 60 | **Prep Helpdesk for full rollout support** | 2012-11-14 → 2013-03-28 (+134d) | 2012-11-14 → 2013-04-04 (+141d) | 1d? → 5d |  | 0d → none | none → 58 |
| 61 | any additional training/documentation | 2012-11-14 → 2013-03-28 (+134d) | 2012-11-14 → 2013-03-29 (+135d) |  |  |  |  |
| 62 | **Full rollout (COMMUNITY)** | 2012-11-14 → 2013-04-04 (+141d) | 2012-11-14 → 2013-04-05 (+142d) | 1d? → 1d |  | 0d → none | none → 60 |
| 63 | Provide software to SWRT for distribution | 2012-11-14 → 2013-04-04 (+141d) | 2012-11-14 → 2013-04-05 (+142d) |  |  |  |  |
| 64 | **MAC Selection** |  | 2012-12-05 → 2013-04-03 (+119d) | 16d? → 101d? | 17% → 16% |  |  |
| 65 | **Evaluation** |  | 2012-12-05 → 2013-01-31 (+57d) | 6d? → 47d? | 70% → 75% |  |  |
| 66 | **Sophos Evaluation** |  | 2012-12-05 → 2013-01-31 (+57d) | 6d? → 47d? | 80% → 75% |  |  |
| 70 | Document Pros and cons | 2012-11-28 → 2013-01-31 (+64d) | 2012-11-28 → 2013-01-31 (+64d) |  |  |  |  |
| 71 | **ESET Evaluation (v5.0 - Jan 2013)** |  | 2012-12-05 → 2013-01-31 (+57d) | 1d? → 42d? | 60% → 75% |  |  |
| 75 | Document pros and cons | 2012-12-05 → 2013-01-31 (+57d) | 2012-12-05 → 2013-01-31 (+57d) |  |  |  |  |
| 76 | **Vendor Demo** | 2012-11-14 A | 2012-11-14 → 2013-02-04 (+82d) | 1d? → 59d? | 0% → 40% |  |  |
| 77 | Determine which vendor(s) to demo | 2012-11-14 A | 2012-11-14 A | 1d? → 1d | 0% → 100% |  |  |
| 78 | Determine invitees | 2012-11-14 A | 2012-11-14 A | 1d? → 1d | 0% → 100% |  |  |
| 79 | Determine requirements | 2012-11-14 → 2013-02-01 (+79d) | 2012-11-14 → 2013-02-01 (+79d) |  |  |  |  |
| 80 | Demo | 2012-11-14 → 2013-02-01 (+79d) | 2012-11-14 → 2013-02-01 (+79d) |  |  |  |  |
| 81 | Team feedback | 2012-11-14 → 2013-02-04 (+82d) | 2012-11-14 → 2013-02-04 (+82d) | 1d? → 1d |  |  | none → 80 |
| 82 | **Analyze Recommendation and Solution** | 2012-11-14 → 2013-02-07 (+85d) | 2012-11-14 → 2013-02-08 (+86d) | 1d? → 2d |  |  |  |
| 83 | Determine any contract/licensing issues | 2012-11-14 → 2013-02-07 (+85d) | 2012-11-14 → 2013-02-08 (+86d) | 1d? → 2d |  |  | none → 40 |
| 84 | Determine total cost of ownership | 2012-11-14 → 2013-02-07 (+85d) | 2012-11-14 → 2013-02-08 (+86d) | 1d? → 2d |  |  | none → 40 |
| 85 | Determine benefits and concerns | 2012-11-14 → 2013-02-07 (+85d) | 2012-11-14 → 2013-02-08 (+86d) | 1d? → 2d |  |  | none → 40 |
| 86 | Determine support process/structure | 2012-11-14 → 2013-02-07 (+85d) | 2012-11-14 → 2013-02-08 (+86d) | 1d? → 2d |  |  | none → 40 |
| 87 | **Sponsor approval** | 2012-11-14 → 2013-02-08 (+86d) | 2012-11-14 → 2013-02-15 (+93d) | 1d? → 5d |  | 0d → none | none → 82 |
| 88 | Approval from sponsor | 2012-11-14 → 2013-02-08 (+86d) | 2012-11-14 → 2013-02-11 (+89d) |  |  |  |  |
| 89 | **Documentation and communication** | 2012-11-14 → 2013-02-18 (+96d) | 2012-11-14 → 2013-02-20 (+98d) | 1d? → 3d |  |  | none → 87 |

| ID | Task | Start | Finish | Duration | Total float | Predecessors |
| --- | --- | --- | --- | --- | --- | --- |
| 90 | Helpdesk (awareness only) | 2012-11-14 → 2013-02-18 (+96d) | 2012-11-14 → 2013-02-18 (+96d) | 1d? → 1d |  | none → 87 |
| 91 | DITR (awareness only) | 2012-11-14 → 2013-02-19 (+97d) | 2012-11-14 → 2013-02-19 (+97d) | 1d? → 1d |  | none → 90 |
| 92 | ITLEADERS (awareness and preparing for early adaptors only) | 2012-11-14 → 2013-02-20 (+98d) | 2012-11-14 → 2013-02-20 (+98d) | 1d? → 1d |  | none → 91 |
| 93 | **Pilot rollout (STAKEHOLDERS)** | 2012-11-14 → 2013-02-18 (+96d) | 2012-11-14 → 2013-02-22 (+100d) | 1d? → 5d |  |  |
| 94 | Determine pilot rollout team | 2012-11-14 → 2013-02-18 (+96d) | 2012-11-14 → 2013-02-18 (+96d) | 1d? → 1d |  | none → 87 |
| 95 | Determine timelines | 2012-11-14 → 2013-02-20 (+98d) | 2012-11-14 → 2013-02-20 (+98d) | 1d? → 1d |  | none → 94 |
| 96 | determine pilot rollout strategy | 2012-11-14 → 2013-02-21 (+99d) | 2012-11-14 → 2013-02-21 (+99d) | 1d? → 1d |  | none → 95 |
| 97 | Collect feedback | 2012-11-14 → 2013-02-22 (+100d) | 2012-11-14 → 2013-02-22 (+100d) | 1d? → 1d |  | none → 96 |
| 98 | **Procurement** | 2012-11-14 → 2013-02-22 (+100d) | 2012-11-14 → 2013-03-08 (+114d) | 1d? → 10d | 0d → none | none → 93 |
| 99 | Negotiate pricing | 2012-11-14 → 2013-02-22 (+100d) | 2012-11-14 → 2013-02-25 (+103d) |  |  |  |
| 100 | Contract agreement and signature | 2012-11-14 → 2013-02-22 (+100d) | 2012-11-14 → 2013-02-25 (+103d) |  |  |  |
| 101 | Purchase | 2012-11-14 → 2013-02-22 (+100d) | 2012-11-14 → 2013-02-25 (+103d) |  |  |  |
| 102 | Reminder: adjust McAfee contract | 2012-11-14 → 2013-02-22 (+100d) | 2012-11-14 → 2013-02-25 (+103d) |  |  |  |
| 103 | **EARLY ADOPTERS** | 2012-11-14 → 2013-03-11 (+117d) | 2012-11-14 → 2013-03-27 (+133d) | 1d? → 13d |  | none → 98 |
| 104 | Determine early adopters participants | 2012-11-14 → 2013-03-11 (+117d) | 2012-11-14 → 2013-03-11 (+117d) | 1d? → 1d |  | none → 98 |
| 105 | Determine timelines | 2012-11-14 → 2013-03-12 (+118d) | 2012-11-14 → 2013-03-12 (+118d) | 1d? → 1d |  | none → 104 |
| 106 | determine beta rollout strategy | 2012-11-14 → 2013-03-13 (+119d) | 2012-11-14 → 2013-03-13 (+119d) | 1d? → 1d |  | none → 105 |
| 107 | collect feedback | 2012-11-14 → 2013-03-14 (+120d) | 2012-11-14 → 2013-03-27 (+133d) | 1d? → 10d |  | none → 106 |
| 108 | Final Checkpoint: Present all feedback including beta rollout feedback to Sponsor | 2012-11-14 → 2013-03-28 (+134d) | 2012-11-14 → 2013-03-28 (+134d) |  |  | none → 106 |
| 109 | **General Communications** | 2012-11-14 → 2013-03-28 (+134d) | 2012-11-14 → 2013-03-29 (+135d) | 1d? → 1d | 0d → none | none → 108 |
| 110 | to community | 2012-11-14 → 2013-03-28 (+134d) | 2012-11-14 → 2013-03-29 (+135d) |  |  |  |
| 111 | **Prep Helpdesk for full rollout support** | 2012-11-14 → 2013-04-01 (+138d) | 2012-11-14 → 2013-04-02 (+139d) | 1d? → 2d |  | none → 109 |
| 112 | any additional training/documentation | 2012-11-14 → 2013-04-01 (+138d) | 2012-11-14 → 2013-04-02 (+139d) | 1d? → 2d |  | none → 109 |
| 113 | **Full rollout (COMMUNITY)** | 2012-11-14 → 2013-04-02 (+139d) | 2012-11-14 → 2013-04-03 (+140d) | 1d? → 1d | 0d → none | none → 111 |
| 114 | Provide software to SWRT for distribution | 2012-11-14 → 2013-04-03 (+140d) | 2012-11-14 → 2013-04-03 (+140d) | 1d? → 1d |  | none → 111 |
| 115 | **Project Wrapup** | 2012-11-14 → 2013-04-03 (+140d) | 2012-11-14 → 2013-04-04 (+141d) |  |  | none → 113 |
| 116 | closeout project | 2012-11-14 → 2013-04-03 (+140d) | 2012-11-14 → 2013-04-04 (+141d) |  |  |  |

## Version 6 (saved 2013-02-04, file Malware Protection Overhaul Feb04.mpp)

Last finish stays 2013-04-05. Complete tasks 22 → 25.

Added:

| ID | Task | Duration | Start | Finish |
| --- | --- | --- | --- | --- |
| 34 | Understand what the license needs are | 1d? | 2012-11-14 | 2012-11-14 |

Removed: 15 Document pros and cons; 20 Document pros and cons

Changed:

| ID | Task | Start | Finish | Duration | Complete | Total float |
| --- | --- | --- | --- | --- | --- | --- |
| 1 | **Malware Protection Overhaul Project** |  |  |  | 20% → 24% |  |
| 10 | **Windows Selection** |  |  |  | 16% → 19% |  |
| 11 | **System Center 2012 (Forefront) Evaluation** |  | 2013-01-31 A | 57d? → 57d | 50% → 100% | 0d → none |
| 14 | Console and client functionality evaluation | 2013-01-31 A | 2013-01-31 A | 1d? → 1d | 0% → 100% |  |
| 15 | **ESET Evaluation (v5.0 - Jan 2013)** |  | 2013-01-31 → 2012-11-14 A (-78d) | 57d? → 1d | 75% → 100% | 0d → none |
| 19 | **Vendor Demo** |  |  |  | 7% → 9% |  |
| 21 | Determine requirements | 2013-02-01 A |  |  | 0% → 20% |  |
| 32 | **McAfee License** |  |  |  | 50% → 33% |  |
| 63 | **MAC Selection** |  |  |  | 16% → 20% |  |
| 64 | **Evaluation** |  | 2013-01-31 A | 47d? → 47d | 75% → 100% | 0d → none |
| 65 | **Sophos Evaluation** |  | 2013-01-31 A | 47d? → 47d | 75% → 100% | 0d → none |
| 69 | Document Pros and cons | 2013-01-31 A | 2013-01-31 A | 1d? → 1d | 0% → 100% |  |
| 70 | **ESET Evaluation (v5.0 - Jan 2013)** |  | 2013-01-31 A | 42d? → 42d | 75% → 100% | 0d → none |
| 74 | Document pros and cons | 2013-01-31 A | 2013-01-31 A | 1d? → 1d | 0% → 100% |  |
| 75 | **Vendor Demo** |  |  |  | 40% → 44% |  |
| 78 | Determine requirements | 2013-02-01 A |  |  | 0% → 20% |  |

## Version 7 (saved 2013-05-09, file Malware Protection Overhaul May09.mpp)

Last finish 2013-04-05 → 2013-06-18 (+74d). Complete tasks 25 → 32.

Added:

| ID | Task | Duration | Start | Finish | Predecessors | Constraint | Resources |
| --- | --- | --- | --- | --- | --- | --- | --- |
| 51 | Setup | 2d | 2013-05-09 | 2013-05-10 |  | start no earlier than 2013-05-09 |  |
| 55 | Pilot rollout (STAKEHOLDERS) | 10d | 2013-05-10 | 2013-05-23 | 54 |  |  |
| 63 | **communicate new solution deployment and maintenance to impacted stakeholders** | 142.1d? | 2012-11-14 A | 2013-05-31 |  |  | Sophie |
| 64 | identify current teams impacted by this change & communicate to them new product and new maintenance structure | 1d | 2012-11-14 A | 2013-05-31 A | 60 |  |  |
| 65 | planning meeting | 1d? | 2012-11-14 | 2012-11-14 |  |  |  |
| 66 | **Setup for distribution** | 1d? | 2013-05-31 | 2013-06-03 |  |  |  |
| 67 | Assist teams in setting up for distribution | 1d? | 2013-05-31 | 2013-06-03 | 64 |  |  |
| 70 | IT Partners presentation | 1d? | 2013-06-13 | 2013-06-13 |  | start no earlier than 2013-06-13 |  |
| 77 | Post project support | 0d | 2013-06-17 | 2013-06-17 | 71 |  |  |

Removed: 51 EARLY ADOPTERS; 52 Determine early adopters participants; 53 Determine timelines; 54 determine beta rollout strategy; 55 collect feedback; 56 Final Checkpoint: Present all feedback including beta rollout feedback to Sponsor; 63 MAC Selection; 64 Evaluation; 75 Vendor Demo; 76 Determine which vendor(s) to demo; 77 Determine invitees; 78 Determine requirements; 79 Demo; 80 Team feedback; 81 Analyze Recommendation and Solution; 82 Determine any contract/licensing issues; 83 Determine total cost of ownership; 84 Determine benefits and concerns; 85 Determine support process/structure; 86 Sponsor approval; 87 Approval from sponsor; 88 Documentation and communication; 89 Helpdesk (awareness only); 90 DITR (awareness only); 91 ITLEADERS (awareness and preparing for early adaptors only); 92 Pilot rollout (STAKEHOLDERS); 93 Determine pilot rollout team; 94 Determine timelines; 95 determine pilot rollout strategy; 96 Collect feedback; 97 Procurement; 98 Negotiate pricing; 99 Contract agreement and signature; 100 Purchase; 101 Reminder: adjust McAfee contract; 102 EARLY ADOPTERS; 103 Determine early adopters participants; 104 Determine timelines; 105 determine beta rollout strategy; 106 collect feedback; 107 Final Checkpoint: Present all feedback including beta rollout feedback to Sponsor; 108 General Communications; 109 to community; 110 Prep Helpdesk for full rollout support; 111 any additional training/documentation; 112 Full rollout (COMMUNITY); 113 Provide software to SWRT for distribution

Changed:

| ID | Task | Start | Finish | Duration | Complete | Total float | Predecessors | Other |
| --- | --- | --- | --- | --- | --- | --- | --- | --- |
| 1 | **Malware Protection Overhaul Project** |  | 2013-04-05 → 2013-06-18 (+74d) | 110d? → 162d? | 24% → 55% |  |  |  |
| 10 | **Vendor Selection** |  | 2013-04-05 → 2013-05-08 A (+33d) | 103d? → 126d | 19% → 100% | 0d → none |  | was named Windows Selection |
| 29 | **Vendor Demo** |  | 2013-02-14 A |  | 9% → 100% | 0d → none |  |  |
| 31 | Determine requirements |  | 2013-02-01 A |  | 20% → 100% |  |  |  |
| 32 | Demo | 2013-02-01 A | 2013-02-14 A |  | 0% → 100% |  |  |  |
| 33 | Team feedback | 2013-02-01 A | 2013-02-04 A |  | 0% → 100% |  |  |  |
| 34 | **Analyze Recommendation and Solution** |  | 2013-02-19 A |  | 20% → 100% | 0d → none |  |  |
| 36 | Determine any contract/licensing issues | 2013-02-15 A | 2013-02-15 A |  | 0% → 100% |  |  |  |
| 37 | Determine total cost of ownership | 2013-02-15 A | 2013-02-15 A |  | 0% → 100% | 0d → none |  |  |
| 38 | Determine benefits and concerns | 2013-02-18 A | 2013-02-18 A |  | 0% → 100% | 0d → none |  |  |
| 39 | Determine support process/structure | 2013-02-19 A | 2013-02-19 A |  | 0% → 100% | 0d → none |  |  |
| 40 | **Sponsor approval** |  |  |  | 0% → 100% |  |  |  |
| 41 | Approval from sponsor | 2013-02-19 → 2013-05-08 A (+78d) | 2013-02-20 → 2013-05-08 A (+77d) | 1d? → 1d | 0% → 100% |  |  |  |
| 42 | **McAfee License** |  | 2013-02-27 → 2013-05-08 (+70d) | 76d? → 126d? | 33% → 50% | 27d → 29d |  | resources none → Sophie |
| 44 | Understand what the license needs are | 2012-11-14 → 2013-05-08 A (+175d) | 2012-11-14 → 2013-05-08 (+175d) | 1d? → 1d | 0% → 50% |  |  |  |
| 46 | **Documentation and communication** | 2013-02-27 → 2013-05-09 (+71d) | 2013-02-27 → 2013-05-09 (+71d) |  |  | -15d → 28d | 40 → 41 | resources none → Sophie |
| 47 | Helpdesk (awareness only) | 2013-02-27 → 2013-05-09 (+71d) | 2013-02-27 → 2013-05-09 (+71d) |  |  | 27d → 28d |  |  |
| 48 | DITR (awareness only) | 2013-02-27 → 2013-05-09 (+71d) | 2013-02-27 → 2013-05-09 (+71d) |  |  | 27d → 28d |  |  |
| 49 | ITLEADERS (awareness and preparing for early adaptors only) | 2013-02-27 → 2013-05-09 (+71d) | 2013-02-27 → 2013-05-09 (+71d) |  |  | -15d → 28d |  |  |
| 50 | **Full Integration Testing** |  |  |  |  |  | 40 → none | was named Pilot rollout (STAKEHOLDERS) |
| 52 | Determine pilot rollout team | 2013-02-26 → 2013-05-09 (+72d) | 2013-02-27 → 2013-05-09 (+71d) |  |  | none → 28d |  | constraint none → start no earlier than 2013-05-09 |
| 53 | Determine timelines | 2013-02-26 → 2013-05-09 (+72d) | 2013-02-27 → 2013-05-09 (+71d) |  |  | none → -42d | none → 41 |  |
| 54 | determine pilot rollout strategy | 2013-02-26 → 2013-05-09 (+72d) | 2013-02-27 → 2013-05-09 (+71d) |  |  | none → -56d | none → 41 |  |
| 56 | Collect feedback | 2013-02-26 → 2013-05-24 (+87d) | 2013-02-27 → 2013-05-24 (+86d) |  |  | none → -56d | none → 55 |  |
| 57 | Checkpoint: Present feedback to Sponsor | 2013-02-26 → 2013-05-27 (+90d) | 2013-02-27 → 2013-05-29 (+91d) | 1d? → 3d |  | none → -56d | none → 56 | was named Checkpoint: Present pilot rollout feedback to Sponsor |
| 58 | **Procurement** | 2013-03-12 → 2013-05-09 (+58d) | 2013-03-26 → 2013-05-31 (+66d) | 10d → 17d? |  | none → 12d | 50 → none |  |
| 59 | Negotiate pricing | 2013-03-12 → 2013-05-09 (+58d) | 2013-03-13 → 2013-05-09 (+57d) |  |  | none → 28d | none → 41 | resources none → Sophie |
| 60 | Contract agreement and signature | 2013-03-12 → 2013-05-30 (+79d) | 2013-03-13 → 2013-05-30 (+78d) |  |  | none → 12d | none → 57 |  |
| 61 | Purchase | 2013-03-12 → 2013-05-31 (+80d) | 2013-03-13 → 2013-05-31 (+79d) |  |  | none → 12d | none → 60 |  |
| 62 | Reminder: adjust McAfee contract | 2013-03-12 → 2013-05-31 (+80d) | 2013-03-13 → 2013-05-31 (+79d) |  |  | none → 12d | none → 60 |  |
| 68 | **General Communications** | 2013-03-26 → 2013-06-03 (+69d) | 2013-03-28 → 2013-06-13 (+77d) | 2d → 8.9d? |  | none → 0d | EARLY ADOPTERS → 66 |  |
| 69 | to community | 2013-03-26 → 2013-06-03 (+69d) | 2013-03-27 → 2013-06-04 (+69d) |  |  | none → 7.9d |  |  |
| 71 | **Prep Helpdesk for full rollout support** | 2013-03-28 → 2013-06-14 (+78d) | 2013-04-04 → 2013-06-14 (+71d) | 5d → 1d? |  | none → 0d |  |  |
| 72 | any additional training/documentation | 2013-03-28 → 2013-06-14 (+78d) | 2013-03-29 → 2013-06-14 (+77d) |  |  | none → 0d |  |  |
| 73 | **Full rollout (COMMUNITY)** | 2013-04-04 → 2013-06-17 (+74d) | 2013-04-05 → 2013-06-17 (+73d) | 1d → 1d? |  | none → 0d | 71 → 72 |  |
| 74 | Provide software to SWRT for distribution | 2013-04-04 → 2013-06-17 (+74d) | 2013-04-05 → 2013-06-17 (+73d) |  |  | none → 0d | none → 72 |  |
| 75 | **Project Wrapup** | 2013-04-03 → 2013-06-18 (+76d) | 2013-04-04 → 2013-06-18 (+75d) |  |  |  | Full rollout (COMMUNITY) → 74 |  |
| 76 | closeout project | 2013-04-03 → 2013-06-18 (+76d) | 2013-04-04 → 2013-06-18 (+75d) |  |  | none → 0d |  |  |
